# prokat

Schedule from MS Project, 2008-04-01 to 2008-07-17.

## Calendars

- Standard: Mon-Fri 08:00-12:00, 13:00-17:00; Sat-Sun off.

## Schedule

| ID | WBS | Task | Type | Duration | Start | Finish | Predecessors | Total slack | Free slack |
| --- | --- | --- | --- | --- | --- | --- | --- | --- | --- |
| 1 | 1 | **Prefab Construction** |  | 77.5d | 2008-04-01 | 2008-07-17 |  | 0d |  |
| 2 | 1.1 | Start | milestone | 0w | 2008-04-01 | 2008-04-01 |  | 0d |  |
| 3 | 1.2 | Supply of prefabrication |  | 6w | 2008-04-01 | 2008-05-12 | 2 | 0d |  |
| 4 | 1.3 | Excavation |  | 1w | 2008-04-01 | 2008-04-07 | 2 | 15d | 0d |
| 5 | 1.4 | Foundation |  | 2w | 2008-04-08 | 2008-04-21 | 4 | 15d |  |
| 6 | 1.5 | Columns |  | 2w | 2008-05-13 | 2008-05-26 | 5, 3 | 0d |  |
| 7 | 1.6 | Wallings |  | 2w | 2008-05-27 | 2008-06-09 | 6 | 0d |  |
| 8 | 1.7 | Electric-Mech Connections |  | 0.5w | 2008-06-10 | 2008-06-12 | 7 | 17.5d | 0d |
| 9 | 1.8 | Floorings |  | 4w | 2008-06-10 | 2008-07-07 | 7 | 0d |  |
| 10 | 1.9 | False roof |  | 0.5d | 2008-06-10 | 2008-06-10 | 7 | 27d |  |
| 11 | 1.10 | Casings, Doors, Windows |  | 1w | 2008-07-08 | 2008-07-14 | 9, 7 | 2.5d |  |
| 12 | 1.11 | Sanitary ware, Kitchen |  | 1.5w | 2008-07-08 | 2008-07-17 | 8, 9 | 0d |  |
| 13 | 1.12 | Roof |  | 1w | 2008-06-12 | 2008-06-19 | 8 | 20d |  |
| 14 | 1.13 | Finish | milestone | 0w | 2008-07-17 | 2008-07-17 | 13, 10, 11, 12 | 0d |  |
