# sumvatiki kataskeui

Schedule from MS Project, 2008-04-01 to 2008-10-06.

## Calendars

- Standard: Mon-Fri 08:00-12:00, 13:00-17:00; Sat-Sun off.

## Schedule

| ID | WBS | Task | Type | Duration | Start | Finish | Predecessors | Total slack | Free slack |
| --- | --- | --- | --- | --- | --- | --- | --- | --- | --- |
| 1 | 1 | **Conventional School Construction** |  | 135d | 2008-04-01 | 2008-10-06 |  | 0d |  |
| 2 | 1.1 | Start | milestone | 0w | 2008-04-01 | 2008-04-01 |  | 0d |  |
| 3 | 1.2 | Excavation |  | 1w | 2008-04-01 | 2008-04-07 | 2 | 0d |  |
| 4 | 1.3 | Foundation |  | 4w | 2008-04-08 | 2008-05-05 | 3 | 0d |  |
| 5 | 1.4 | Concrete columns |  | 5w | 2008-05-06 | 2008-06-09 | 4 | 0d |  |
| 6 | 1.5 | Concrete footplate |  | 2w | 2008-06-10 | 2008-06-23 | 5 | 0d |  |
| 7 | 1.6 | Wallings |  | 4w | 2008-06-24 | 2008-07-21 | 6 | 0d |  |
| 8 | 1.7 | Mortar plasters |  | 2w | 2008-07-22 | 2008-08-04 | 7 | 27.5d | 15d |
| 9 | 1.8 | Electrical-Mechanical Installings |  | 5w | 2008-07-22 | 2008-08-25 | 7 | 0d |  |
| 10 | 1.9 | Floorings (internar-external) |  | 6w | 2008-08-26 | 2008-10-06 | 9 | 0d |  |
| 11 | 1.10 | Paintings |  | 2w | 2008-08-26 | 2008-09-08 | 9, 8 | 12.5d | 0d |
| 12 | 1.11 | False roofs |  | 0.5w | 2008-08-26 | 2008-08-28 | 7, 9 | 27.5d |  |
| 13 | 1.12 | Casings, Doors, Windows |  | 1w | 2008-09-09 | 2008-09-15 | 8, 11 | 15d |  |
| 14 | 1.13 | Kitchen, Sanitary - ware |  | 1.5w | 2008-09-09 | 2008-09-18 | 7, 9, 11 | 12.5d |  |
| 15 | 1.14 | Roof |  | 8w | 2008-07-22 | 2008-09-15 | 7 | 15d |  |
| 16 | 1.15 | Finish | milestone | 0w | 2008-10-06 | 2008-10-06 | 15, 10, 12, 13, 14 | 0d |  |
